# Simple Project Plan

Schedule from MS Project, 2022-05-19 to 2022-07-01.
Microsoft Corporation

## Calendars

- Стандартный: Mon-Fri 09:00-13:00, 14:00-18:00; Sat-Sun off.

## Schedule

| ID | WBS | Task | Type | Duration | Start | Finish | Predecessors | Total slack | Free slack | Constraint |
| --- | --- | --- | --- | --- | --- | --- | --- | --- | --- | --- |
| 1 | 1 | **1 Этап. Изменения в БП движения Заказа** |  | 6d | 2022-05-19 | 2022-05-26 |  | 0d |  |  |
| 2 | 1.1 | Актуализация комплектаций |  | 1d | 2022-05-24 | 2022-05-24 |  | 26d | 0d | start no earlier than 2022-05-24 |
| 3 | 1.2 | Автоприостановка операций по окончанию смены |  | 2d | 2022-05-25 | 2022-05-26 | 2 | 26d |  |  |
| 4 | 1.3 | Не показывать некоторые работы в планшете | manual | 2d | 2022-05-19 | 2022-05-20 |  |  |  |  |
| 5 | 2 | **2 Этап. Фиксация ресурсов** |  | 5d | 2022-05-23 | 2022-05-27 |  | 0d |  |  |
| 6 | 2.1 | Фиксация работы по РЦ |  | 2d | 2022-05-23 | 2022-05-24 | 4 | 0d |  |  |
| 7 | 2.2 | Расчет плана производства с учетом зафиксированного РЦ | manual | 3d | 2022-05-25 | 2022-05-27 | 6 |  |  |  |
| 8 | 3 | **3 этап. Учет на складе выполненных работ** |  | 25d | 2022-05-30 | 2022-07-01 |  | 0d |  |  |
| 9 | 3.1 | Формировать остаток и резерв полуфабриката после выполнения операции | manual | 2d | 2022-05-30 | 2022-05-31 | 7 |  |  |  |
| 10 | 3.2 | Списывание полуфабрикатов и расходных материалов после выполнения операций | manual | 2d | 2022-06-01 | 2022-06-02 | 9 |  |  |  |
| 11 | 3.3 | Создание документа при внесении брака | manual | 2d | 2022-06-03 | 2022-06-06 | 10 |  |  |  |
| 12 | 3.4 | Формирование дополнительных работ при браке | manual | 4d | 2022-06-07 | 2022-06-10 | 11 |  |  |  |
| 13 | 3.5 | **4 этап. Учет и планирование после выполнения работ** |  | 7d | 2022-06-13 | 2022-06-21 |  | 0d |  |  |
| 14 | 3.5.1 | Частичное закрытие операции | manual | 3d | 2022-06-13 | 2022-06-15 | 12 |  |  |  |
| 15 | 3.5.2 | Расстановка работ с учетом оставшегося количества | manual | 2d | 2022-06-16 | 2022-06-17 | 14 |  |  |  |
| 16 | 3.5.3 | Изменения отображения работ на планшете | manual | 2d | 2022-06-20 | 2022-06-21 | 15 |  |  |  |
| 17 | 3.6 | **5 этап. Испытание и документы ОТК** |  | 2d | 2022-06-22 | 2022-06-23 |  | 0d |  |  |
| 18 | 3.6.1 | Возврат из испытания на доработку | manual | 2d | 2022-06-22 | 2022-06-23 | 16 |  |  |  |
| 19 | 3.7 | **6 этап. Изменения в нарядах исполнителей** |  | 2d | 2022-06-24 | 2022-06-27 |  | 0d |  |  |
| 20 | 3.7.1 | Ограничение работ по табелю сотрудника | manual | 2d | 2022-06-24 | 2022-06-27 | 18 |  |  |  |
| 21 | 3.8 | **Совмещать работы по дате клиентские и внутренние заказы по изделиям** |  | 4d | 2022-06-28 | 2022-07-01 |  | 0d |  |  |
| 22 | 3.8.1 | Поиск изделий по внутренним заказам и работы внутреннего заказа совмещать с клиентскими | manual | 4d | 2022-06-28 | 2022-07-01 | 20 |  |  |  |

Notes:
- 1: Это суммарная задача. Используйте суммарные задачи для организации проекта в виде разделов.
- 9: Задачи с кнопкой рядом с ними запланированы вручную. Используйте их, если вы не хотите, чтобы Project перемещал задачу. Также в полях длительности, начала и завершения можно ввести произвольный текст или вы можете оставить их пустыми, если все нужные данные еще недоступны.
